# created_wbs

How a schedule from MS Project changed from version to version. A marks actual dates.

## Version 1 (saved 2016-06-24, file itp-3_-_project_scheddependency_links2.mpp)

| ID | WBS | Task | Duration | Start | Finish | Predecessors | Total float | Constraint |
| --- | --- | --- | --- | --- | --- | --- | --- | --- |
| 1 | 1 | **IT SYSTEM FOR MARLEY'S DENTAL CLINIC** | 109d | 2016-01-01 | 2016-06-01 |  |  |  |
| 2 | 1.1 | **Develop Budget** | 21d | 2016-01-01 | 2016-01-29 |  | 5d |  |
| 3 |  | Determine Support Cost | 2d | 2016-01-01 | 2016-01-04 |  | 5d |  |
| 4 |  | Determine Software Cost | 3d | 2016-01-04 | 2016-01-06 |  | 105d | start no earlier than 2016-01-04 |
| 5 |  | Determine Hardware Costs | 3d | 2016-01-06 | 2016-01-08 |  | 103d | start no earlier than 2016-01-06 |
| 6 |  | Determine Labor and Human Resources Costs | 4d | 2016-01-11 | 2016-01-14 |  | 99d | start no earlier than 2016-01-11 |
| 7 |  | Create Annual Budget Recommendation | 2d | 2016-01-15 | 2016-01-18 |  | 97d | start no earlier than 2016-01-15 |
| 8 | 1.1.6 | **Design of the IT system** | 19d | 2016-01-05 | 2016-01-29 | 3 | 2d |  |
| 9 |  | Design data access | 2d | 2016-01-05 | 2016-01-06 |  | 5d |  |
| 10 |  | Establish who can access data | 3d | 2016-01-07 | 2016-01-11 | 9 | 16d |  |
| 11 | 1.1.6.3 | **Develop secure systems for data storage** | 6d | 2016-01-14 | 2016-01-21 | 9 |  |  |
| 12 |  | Develop data back-up system | 4d | 2016-01-14 | 2016-01-19 |  | 0d |  |
| 13 |  | Develop how to provide electronic version of patient data to patients if required | 2d | 2016-01-20 | 2016-01-21 | 12 | 0d |  |
| 14 |  | Develop separate ID for data attained via telemedicine | 1d | 2016-01-20 | 2016-01-20 | 12 | 9d |  |
| 15 |  | Determine Security Software | 2d | 2016-01-21 | 2016-01-22 | 12 | 7d | start no earlier than 2016-01-21 |
| 16 |  | Create Security Policies | 3d | 2016-01-25 | 2016-01-27 |  | 4d | start no earlier than 2016-01-25 |
| 17 |  | Determine Firewall Configuration | 2d | 2016-01-28 | 2016-01-29 |  | 2d | start no earlier than 2016-01-28 |
| 18 | 1.2 | **Order software** | 3d | 2016-02-01 | 2016-02-03 | 8 |  |  |
| 19 |  | Write up purchase orders | 1d | 2016-02-01 | 2016-02-01 |  | 2d |  |
| 20 | 1.3 | **Order networking** | 1d | 2016-02-05 | 2016-02-05 | 8 |  |  |
| 21 |  | Write up purchase orders | 1d | 2016-02-05 | 2016-02-05 |  | 0d |  |
| 22 |  | Await deliveries and receivership of orders | 5d | 2016-02-01 | 2016-02-05 | 8 | 83d |  |
| 23 | 1.5 | **Install hardware** | 10d | 2016-02-08 | 2016-02-19 | 18, 20 | 1d |  |
| 24 |  | Determine needs for each office | 5d | 2016-02-08 | 2016-02-12 |  | 6d |  |
| 25 |  | Determine room readiness | 5d | 2016-02-08 | 2016-02-12 |  | 6d |  |
| 26 |  | Determine room layouts and specifications | 5d | 2016-02-08 | 2016-02-12 |  | 6d |  |
| 27 |  | Configure hardware | 10d | 2016-02-08 | 2016-02-19 |  | 1d |  |
| 28 |  | Determine technical defects | 6d | 2016-02-08 | 2016-02-15 |  | 2d |  |
| 29 |  | Determine defects and make fixes | 4d | 2016-02-08 | 2016-02-11 |  | 7d |  |
| 30 |  | Remedy technical defects | 3d | 2016-02-08 | 2016-02-10 |  | 5d |  |
| 31 |  | Verify defect fixes | 3d | 2016-02-16 | 2016-02-18 | 28, 30 | 2d |  |
| 32 | 1.6 | **Install Software** | 12d | 2016-02-22 | 2016-03-08 | 23 | 1d |  |
| 33 |  | Install patient registration component | 12d | 2016-02-22 | 2016-03-08 |  | 1d |  |
| 34 |  | Check on Cisco Vital Software Interface requirements | 12d | 2016-02-22 | 2016-03-08 |  | 1d |  |
| 35 |  | Verify that Cisco Vital Software and Third Party medical devices meet requirements | 12d | 2016-02-22 | 2016-03-08 |  | 1d |  |
| 36 |  | Procude mockups with hyperlinks to requirements | 12d | 2016-02-22 | 2016-03-08 |  | 1d |  |
| 37 |  | System testing | 12d | 2016-02-22 | 2016-03-08 |  | 1d |  |
| 38 |  | Develop user interface | 12d | 2016-02-22 | 2016-03-08 |  | 1d |  |
| 39 |  | Configure the software | 12d | 2016-02-22 | 2016-03-08 |  | 1d |  |
| 40 |  | Perform integration testing | 12d | 2016-02-22 | 2016-03-08 |  | 1d |  |
| 41 | 1.7 | **Install networking** | 26d | 2016-03-08 | 2016-04-12 | 32 |  |  |
| 42 |  | Determine network needs | 8d | 2016-03-08 | 2016-03-17 |  | 18d |  |
| 43 |  | Determine networking infrastructure needs | 8d | 2016-03-08 | 2016-03-17 |  | 2d |  |
| 44 |  | Configure Financial Management Software | 3d | 2016-03-18 | 2016-03-22 | 43 | 2d |  |
| 45 |  | Configure Insurance Management Software | 4d | 2016-03-23 | 2016-03-28 | 44 | 2d |  |
| 46 |  | Configure Xray Management Software | 4d | 2016-03-29 | 2016-04-01 | 45 | 2d |  |
| 47 |  | Test all software | 5d | 2016-04-04 | 2016-04-08 | 46 | 2d |  |
| 48 | 1.8 | **Create management protocol** | 5d | 2016-04-08 | 2016-04-14 |  |  |  |
| 49 |  | Create maintenance plan | 1d | 2016-04-08 | 2016-04-08 |  | 4d |  |
| 50 |  | Create maintenance notification messaging | 1d | 2016-04-08 | 2016-04-08 |  | 4d |  |
| 51 | 1.9 | **Manage the project and team** | 9d | 2016-04-15 | 2016-04-27 | 48 | 4d |  |
| 52 | 1.9.1 | **Review of the workplan** | 5d | 2016-04-21 | 2016-04-27 |  |  |  |
| 53 |  | Identify completed activities | 3d | 2016-04-21 | 2016-04-25 |  | 2d |  |
| 54 |  | Check for variances in the schedule | 3d | 2016-04-21 | 2016-04-25 |  | 2d |  |
| 55 |  | Review the team morale | 3d | 2016-04-15 | 2016-04-19 |  | 20d |  |
| 56 | 1.10 | **Control of the Project** | 3d | 2016-04-15 | 2016-04-19 | 48 | 20d |  |
| 57 |  | Guard against scope creep | 3d | 2016-04-15 | 2016-04-19 |  | 20d |  |
| 58 |  | Check for the need for scope changes | 3d | 2016-04-15 | 2016-04-19 |  | 20d |  |
| 59 | 1.11 | **Monitor the Project** | 3d | 2016-04-15 | 2016-04-19 | 48 | 20d |  |
| 60 |  | Evaluate project deliverables | 3d | 2016-04-15 | 2016-04-19 |  | 20d |  |
| 61 |  | Check on the budget | 3d | 2016-04-15 | 2016-04-19 |  | 20d |  |
| 62 | 1.12 | **Project Meetings and Training** | 19d | 2016-04-28 | 2016-05-24 | 51, 56, 59 | 0d |  |
| 63 |  | Define users | 1d | 2016-04-28 | 2016-04-28 |  | 18d |  |
| 64 |  | Explain in basic terms how systems hardware and software works | 1d | 2016-04-28 | 2016-04-28 |  | 18d |  |
| 65 |  | Explain how to interpret data | 1d | 2016-04-28 | 2016-04-28 |  | 18d |  |
| 66 |  | Explain how to store data properly | 1d | 2016-04-28 | 2016-04-28 |  | 18d |  |
| 67 |  | Receptionist Training | 5d | 2016-05-03 | 2016-05-09 |  | 11d | start no earlier than 2016-05-03 |
| 68 |  | Dental Staff Training | 5d | 2016-05-10 | 2016-05-16 |  | 6d | start no earlier than 2016-05-10 |
| 69 |  | Accounting and Administrative Training | 5d | 2016-05-16 | 2016-05-20 |  | 2d | start no earlier than 2016-05-16 |
| 70 |  | Quiz session | 1d | 2016-05-23 | 2016-05-23 |  | 0d | start no earlier than 2016-05-23 |

| ID | WBS | Task | Duration | Start | Finish | Predecessors | Total float | Constraint |
| --- | --- | --- | --- | --- | --- | --- | --- | --- |
| 71 |  | List responsibilities of IT liaison | 1d | 2016-05-24 | 2016-05-24 | 70 | 0d |  |
| 72 | 1.13 | **Project close-out** | 4d | 2016-05-25 | 2016-05-30 | 62 |  |  |
| 73 |  | Close out documentation | 2d | 2016-05-25 | 2016-05-26 |  | 0d |  |
| 74 |  | Outline lessons learned | 2d | 2016-05-27 | 2016-05-30 | 73 | 0d |  |
| 75 |  | Project closure phase complete | 1d | 2016-05-30 | 2016-05-30 | 73 | 2d | start no earlier than 2016-05-30 |

## Version 2 (saved 2016-07-04, file project_resources__costs.mpp)

Last finish stays 2016-06-01.

Added:

| ID | Task | Duration | Start | Finish | Predecessors | Constraint | Resources |
| --- | --- | --- | --- | --- | --- | --- | --- |
| 8 | Retrieve Budget Acceptance Document | 1d | 2016-01-01 | 2016-01-01 |  |  | Project Manager [50%]; Purchase Controller [50%] |
| 11 | Develop Secure systems for data storage | 6d? | 2016-01-07 | 2016-01-14 | 10 |  | Cybersecurity Analyst |
| 23 | Purchase laptops | 1d | 2016-02-01 | 2016-02-01 |  | start no earlier than 2016-02-01 | Purchase Controller |
| 24 | Purchase printers | 1d | 2016-02-01 | 2016-02-01 |  | start no earlier than 2016-02-01 | Purchase Controller |
| 25 | Purchase Rack Router | 1d | 2016-02-01 | 2016-02-01 |  | start no earlier than 2016-02-01 | Purchase Controller |
| 26 | Purchase Server Room Switch | 1d | 2016-02-01 | 2016-02-01 |  | start no earlier than 2016-02-01 | Purchase Controller |
| 27 | Purchase WiFi Router | 1d | 2016-02-01 | 2016-02-01 |  | start no earlier than 2016-02-01 | Purchase Controller |
| 28 | Purchase WiFi Range Extender | 1d | 2016-02-01 | 2016-02-01 |  | start no earlier than 2016-02-01 | Purchase Controller |
| 29 | Purchase Firewall | 1d | 2016-02-01 | 2016-02-01 |  | start no earlier than 2016-02-01 | Purchase Controller |

Removed: 11 Develop secure systems for data storage; 22 Await deliveries and receivership of orders

Changed:

| ID | Task | Start | Finish | Duration | Total float | Predecessors | Other |
| --- | --- | --- | --- | --- | --- | --- | --- |
| 2 | **Develop Budget** |  | 2016-01-29 → 2016-01-18 (-11d) | 21d → 12d | 5d → none |  |  |
| 3 | Determine Support Cost |  |  |  | 5d → 97d |  | resources none → Purchase Controller |
| 4 | Determine Software Cost |  | 2016-01-06 → 2016-01-05 (-1d) | 3d → 2d | 105d → 106d |  | resources none → Purchase Controller |
| 5 | Determine Hardware Costs |  | 2016-01-08 → 2016-01-07 (-1d) | 3d → 2d | 103d → 104d |  | resources none → Purchase Controller |
| 6 | Determine Labor and Human Resources Costs |  | 2016-01-14 → 2016-01-12 (-2d) | 4d → 2d | 99d → 101d |  | resources none → Purchase Controller |
| 7 | Create Annual Budget Recommendation |  |  |  |  |  | resources none → Purchase Controller |
| 9 | **Design of the IT system** |  | 2016-01-29 → 2016-01-28 (-1d) | 19d → 18d? | 2d → 88d |  |  |
| 10 | Design data access |  |  |  | 5d → 97d |  | resources none → Cybersecurity Analyst |
| 12 | Establish who can access data | 2016-01-07 → 2016-01-15 (+8d) | 2016-01-11 → 2016-01-15 (+4d) | 3d → 1d | 16d → 97d | 10 → 11 | resources none → Network Consultant |
| 13 | Develop data back-up system | 2016-01-14 → 2016-01-05 (-9d) | 2016-01-19 → 2016-01-08 (-11d) |  | 0d → 100d |  | resources none → Cybersecurity Analyst |
| 14 | Develop how to provide electronic version of patient data to patients if required | 2016-01-20 → 2016-01-05 (-15d) | 2016-01-21 → 2016-01-06 (-15d) |  | 0d → 104d | 13 → none | resources none → Cybersecurity Analyst |
| 15 | Develop separate ID for data attained via telemedicine | 2016-01-20 → 2016-01-11 (-9d) | 2016-01-20 → 2016-01-11 (-9d) |  | 9d → 101d |  | resources none → Cybersecurity Analyst |
| 16 | Determine Security Software |  |  |  | 7d → 92d |  | resources none → Cybersecurity Analyst |
| 17 | Create Security Policies |  | 2016-01-27 → 2016-01-25 (-2d) | 3d → 1d | 4d → 91d |  | resources none → Cybersecurity Analyst |
| 18 | Determine Firewall Configuration |  | 2016-01-29 → 2016-01-28 (-1d) | 2d → 1d | 2d → 88d |  | resources none → Network Consultant |
| 19 | **Order software** |  | 2016-02-03 → 2016-02-05 (+2d) | 3d → 5d |  |  | resources none → Intuit QuickBooks 2016 [1 License]; Symantec Antivirus [14 License]; Claims Software [14 License]; Google Apps [14 License]; Oracle Database Software [1 License] |
| 20 | Write up purchase orders and purchase software |  |  |  | 2d → 87d |  | was named Write up purchase orders; constraint none → start no earlier than 2016-02-01; resources none → Business Administrator |
| 21 | **Order networking and hardware** | 2016-02-05 → 2016-02-01 (-4d) | 2016-02-05 → 2016-02-04 (-1d) | 1d → 4d |  |  | was named Order networking; resources none → Broadband Service [1 License]; Cat 6e Cable [1 Unit]; Docking Station [14 Unit]; Firewall [1 Unit]; Junction Box [2 Unit]; Keyboard/Mouse [14 Unit]; Laptop [14 Unit]; Monitor [14 Unit]; Printer [1 Unit]; RJ-45 Connector Tips [2 Pack]; RJ-45 Outlet [14 Unit]; Router [1 Unit]; Surge Protector [14 Unit]; Switch [1 Unit]; WiFi Range Extender [1 Unit]; WiFi Router [1 Unit] |
| 22 | Write up purchase orders | 2016-02-05 → 2016-02-01 (-4d) | 2016-02-05 → 2016-02-01 (-4d) |  | 0d → 87d |  | constraint none → start no earlier than 2016-02-01; resources none → Business Administrator |
| 30 | **Install hardware** |  | 2016-02-19 → 2016-02-12 (-7d) | 10d → 5d | 1d → 58d |  |  |
| 31 | Determine needs for each office |  | 2016-02-12 → 2016-02-10 (-2d) | 5d → 3d | 6d → 60d |  | resources none → Project Manager |
| 32 | Determine room readiness |  | 2016-02-12 → 2016-02-08 (-4d) | 5d → 1d | 6d → 62d |  | resources none → Infrastructure Engineer |
| 33 | Determine room layouts and specifications |  | 2016-02-12 → 2016-02-09 (-3d) | 5d → 2d | 6d → 61d |  | resources none → Infrastructure Engineer |
| 34 | Configure hardware |  | 2016-02-19 → 2016-02-10 (-9d) | 10d → 3d | 1d → 60d |  | resources none → Infrastructure Engineer |
| 35 | Determine technical defects |  | 2016-02-15 → 2016-02-11 (-4d) | 6d → 4d | 2d → 58d |  | resources none → Infrastructure Engineer |
| 36 | Determine defects and make fixes |  | 2016-02-11 → 2016-02-10 (-1d) | 4d → 3d | 7d → 60d |  | resources none → Infrastructure Engineer |
| 37 | Remedy technical defects |  |  |  | 5d → 59d |  | resources none → Infrastructure Engineer |
| 38 | Verify defect fixes | 2016-02-16 → 2016-02-12 (-4d) | 2016-02-18 → 2016-02-12 (-6d) | 3d → 1d | 2d → 58d |  | resources none → Infrastructure Engineer |
| 39 | **Install Software** | 2016-02-22 → 2016-02-15 (-7d) | 2016-03-08 → 2016-02-19 (-18d) | 12d → 5d | 1d → 58d |  | resources none → HIPAA Auditor |
| 40 | Install patient registration component | 2016-02-22 → 2016-02-15 (-7d) | 2016-03-08 → 2016-02-19 (-18d) | 12d → 5d | 1d → 58d |  | resources none → Infrastructure Engineer |
| 41 | Check on Cisco Vital Software Interface requirements | 2016-02-22 → 2016-02-15 (-7d) | 2016-03-08 → 2016-02-15 (-22d) | 12d → 1d | 1d → 62d |  | resources none → Network Consultant |
| 42 | Verify that Cisco Vital Software and Third Party medical devices meet requirements | 2016-02-22 → 2016-02-15 (-7d) | 2016-03-08 → 2016-02-17 (-20d) | 12d → 3d | 1d → 60d |  | resources none → Project Manager |
| 43 | Produce mockups with hyperlinks to requirements | 2016-02-22 → 2016-02-15 (-7d) | 2016-03-08 → 2016-02-17 (-20d) | 12d → 3d | 1d → 60d |  | was named Procude mockups with hyperlinks to requirements; resources none → Network Consultant |
| 44 | System testing | 2016-02-22 → 2016-02-15 (-7d) | 2016-03-08 → 2016-02-19 (-18d) | 12d → 5d | 1d → 58d |  | resources none → Network Consultant |
| 45 | Develop user interface | 2016-02-22 → 2016-02-15 (-7d) | 2016-03-08 → 2016-02-18 (-19d) | 12d → 4d | 1d → 59d |  | resources none → Infrastructure Engineer |
| 46 | Configure the software | 2016-02-22 → 2016-02-15 (-7d) | 2016-03-08 → 2016-02-18 (-19d) | 12d → 4d | 1d → 59d |  | resources none → Infrastructure Engineer |
| 47 | Perform integration testing | 2016-02-22 → 2016-02-15 (-7d) | 2016-03-08 → 2016-02-19 (-18d) | 12d → 5d | 1d → 58d |  | resources none → Infrastructure Engineer |
| 49 | Determine network needs |  | 2016-03-17 → 2016-03-08 (-9d) | 8d → 1d | 18d → 61d |  | resources none → Infrastructure Engineer |
| 50 | Determine networking infrastructure needs |  | 2016-03-17 → 2016-03-08 (-9d) | 8d → 1d | 2d → 47d |  | resources none → Infrastructure Engineer |
| 51 | Configure Financial Management Software | 2016-03-18 → 2016-03-09 (-9d) | 2016-03-22 → 2016-03-11 (-11d) |  | 2d → 47d |  | resources none → Software Development Manager |
| 52 | Configure Insurance Management Software | 2016-03-23 → 2016-03-14 (-9d) | 2016-03-28 → 2016-03-16 (-12d) | 4d → 3d | 2d → 47d |  | resources none → Software Development Manager |
| 53 | Configure Xray Management Software | 2016-03-29 → 2016-03-17 (-12d) | 2016-04-01 → 2016-03-21 (-11d) | 4d → 3d | 2d → 47d |  | resources none → Software Development Manager |
| 54 | Test all software | 2016-04-04 → 2016-03-22 (-13d) | 2016-04-08 → 2016-03-28 (-11d) |  | 2d → 47d |  | resources none → QA Engineer |
| 56 | Create maintenance plan |  |  |  | 4d → 8d |  | resources none → Cybersecurity Analyst |
| 57 | Create maintenance notification messaging |  |  |  | 4d → 8d |  | resources none → Cybersecurity Analyst |
| 60 | Identify completed activities |  |  |  | 2d → 21d |  | resources none → Project Manager |
| 61 | Check for variances in the schedule |  |  |  | 2d → 21d |  | resources none → Associate Project Manager |
| 62 | Review the team morale |  |  |  | 20d → 25d |  | resources none → Associate Project Manager |
| 64 | Guard against scope creep |  |  |  | 20d → 25d |  | resources none → Project Manager |
| 65 | Check for the need for scope changes |  |  |  | 20d → 25d |  | resources none → Project Manager |
| 67 | Evaluate project deliverables |  |  |  | 20d → 25d |  | resources none → Project Manager |
| 68 | Check on the budget |  |  |  | 20d → 25d |  | resources none → Finance Manager |
| 70 | Define users |  |  |  | 18d → 22d |  | resources none → Network Consultant |
| 71 | Explain in basic terms how systems hardware and software works |  |  |  | 18d → 22d |  | resources none → Software Development Manager |
| 72 | Explain how to interpret data |  |  |  | 18d → 22d |  | resources none → Database Manager |
| 73 | Explain how to store data properly |  |  |  | 18d → 22d |  | resources none → Database Manager |
| 74 | Receptionist Training |  | 2016-05-09 → 2016-05-03 (-6d) | 5d → 1d | 11d → 19d |  | resources none → Trainer |
| 75 | Dental Staff Training |  | 2016-05-16 → 2016-05-13 (-3d) | 5d → 4d | 6d → 11d |  | resources none → Trainer |
| 76 | Accounting and Administrative Training |  | 2016-05-20 → 2016-05-19 (-1d) | 5d → 4d | 2d → 7d |  | resources none → Trainer |
| 77 | Quiz session |  |  |  | 0d → 4d |  | resources none → Business Administrator |
| 78 | List responsibilities of IT liaison |  |  |  | 0d → 4d |  | resources none → Project Manager |
| 80 | Establish Feedback System |  | 2016-05-26 → 2016-05-25 (-1d) | 2d → 1d | 0d → 4d |  | was named Close out documentation; resources none → Project Manager |
| 81 | Outline lessons learned | 2016-05-27 → 2016-05-26 (-1d) | 2016-05-30 → 2016-05-26 (-4d) | 2d → 1d | 0d → 4d |  | resources none → Project Manager |
| 82 | Close out documentation and signatures |  |  | 1d → 0.5d | 2d → 2.5d |  | was named Project closure phase complete; resources none → Associate Project Manager; Project Manager |

## Version 3 (data date 2016-03-01, saved 2016-07-24, file updated_project_wbs.mpp)

Last finish 2016-06-01 → 2016-10-06 (+127d). Complete tasks 0 → 20.

Added:

| ID | Task | Duration | Start | Finish | Predecessors | Resources |
| --- | --- | --- | --- | --- | --- | --- |
| 11 | **1.2.3 Develop secure systems for data storage** | 6d | 2016-01-14 A | 2016-01-21 | 9 | Cybersecurity Analyst |
| 22 | 1.4.2 Await deliveries and receivership of orders | 10d | 2016-02-01 A | 2016-02-12 A | 8 |  |

Removed: 8 Retrieve Budget Acceptance Document; 11 Develop Secure systems for data storage; 23 Purchase laptops; 24 Purchase printers; 25 Purchase Rack Router; 26 Purchase Server Room Switch; 27 Purchase WiFi Router; 28 Purchase WiFi Range Extender; 29 Purchase Firewall

Changed:

| ID | Task | Start | Finish | Duration | Complete | Total float | Predecessors | Other |
| --- | --- | --- | --- | --- | --- | --- | --- | --- |
| 1 | **1 IT SYSTEM FOR MARLEY'S DENTAL CLINIC** | 2016-01-01 A |  |  | 0% → 25% |  |  | was named IT SYSTEM FOR MARLEY'S DENTAL CLINIC; baseline start none → 2016-01-01; baseline finish none → 2016-06-01 |
| 2 | **1.1 Develop Budget** | 2016-01-01 A | 2016-01-18 → 2016-01-29 (+11d) | 12d → 21d | 0% → 99% | none → 0d |  | was named Develop Budget; baseline start none → 2016-01-01; baseline finish none → 2016-01-29 |
| 3 | 1.1.1 Determine Support Cost | 2016-01-01 A | 2016-01-04 A |  | 0% → 100% | 97d → none |  | was named Determine Support Cost; baseline start none → 2016-01-01; baseline finish none → 2016-01-04 |
| 4 | 1.1.2 Determine Software Cost | 2016-01-04 → 2016-01-05 A (+1d) | 2016-01-05 → 2016-01-20 A (+15d) | 2d → 3d | 0% → 100% | 106d → none |  | was named Determine Software Cost; baseline start none → 2016-01-05; baseline finish none → 2016-01-20 |
| 5 | 1.1.3 Determine Hardware Costs | 2016-01-06 A | 2016-01-07 → 2016-01-08 A (+1d) | 2d → 3d | 0% → 100% | 104d → none |  | was named Determine Hardware Costs; baseline start none → 2016-01-06; baseline finish none → 2016-01-08 |
| 6 | 1.1.4 Determine Labor and Human Resources Costs | 2016-01-11 A | 2016-01-12 → 2016-01-14 A (+2d) | 2d → 4d | 0% → 100% | 101d → none |  | was named Determine Labor and Human Resources Costs; baseline start none → 2016-01-11; baseline finish none → 2016-01-14 |
| 7 | 1.1.5 Create Annual Budget Recommendation | 2016-01-15 A | 2016-01-18 A |  | 0% → 100% | 97d → none |  | was named Create Annual Budget Recommendation; baseline start none → 2016-01-15; baseline finish none → 2016-01-18 |
| 8 | **1.2 Design of the IT system** | 2016-01-05 A | 2016-01-28 → 2016-01-29 (+1d) | 18d? → 19d | 0% → 99% | 88d → 0d |  | was named Design of the IT system; baseline start none → 2016-01-05; baseline finish none → 2016-01-29 |
| 9 | 1.2.1 Design data access | 2016-01-05 A | 2016-01-06 A |  | 0% → 100% | 97d → none |  | was named Design data access; baseline start none → 2016-01-05; baseline finish none → 2016-01-06 |
| 10 | 1.2.2 Establish who can access data | 2016-01-15 → 2016-01-07 A (-8d) | 2016-01-15 → 2016-01-11 A (-4d) | 1d → 3d | 0% → 100% | 97d → none | Develop Secure systems for data storage → 9 | was named Establish who can access data; resources Network Consultant → Cybersecurity Analyst; baseline start none → 2016-01-07; baseline finish none → 2016-01-11 |
| 12 | 1.2.3.1 Develop data back-up system | 2016-01-05 → 2016-01-14 A (+9d) | 2016-01-08 → 2016-01-19 A (+11d) |  | 0% → 100% | 100d → none |  | was named Develop data back-up system; baseline start none → 2016-01-14; baseline finish none → 2016-01-19 |
| 13 | 1.2.3.2. Develop how to provide electronic version of patient data to patients if required | 2016-01-05 → 2016-01-20 A (+15d) | 2016-01-06 → 2016-01-21 A (+15d) |  | 0% → 100% | 104d → none | none → 12 | was named Develop how to provide electronic version of patient data to patients if required; baseline start none → 2016-01-20; baseline finish none → 2016-01-21 |
| 14 | 1.2.4 Develop separate ID for data attained via telemedicine | 2016-01-11 → 2016-01-22 A (+11d) | 2016-01-11 → 2016-01-22 A (+11d) |  | 0% → 100% | 101d → none |  | was named Develop separate ID for data attained via telemedicine; baseline start none → 2016-01-22; baseline finish none → 2016-01-22 |
| 15 | 1.2.5 Determine Security Software | 2016-01-21 → 2016-01-28 A (+7d) | 2016-01-22 → 2016-01-29 A (+7d) |  | 0% → 100% | 92d → none |  | was named Determine Security Software; baseline start none → 2016-01-28; baseline finish none → 2016-01-29 |
| 16 | 1.2.6 Create Security Policies | 2016-01-25 A | 2016-01-25 → 2016-01-27 A (+2d) | 1d → 3d | 0% → 100% | 91d → none |  | was named Create Security Policies; baseline start none → 2016-01-25; baseline finish none → 2016-01-27 |
| 17 | 1.2.7 Determine Firewall Configuration | 2016-01-28 A | 2016-01-28 → 2016-01-29 A (+1d) | 1d → 2d | 0% → 100% | 88d → none |  | was named Determine Firewall Configuration; baseline start none → 2016-01-28; baseline finish none → 2016-01-29 |
| 18 | **1.3 Order software** | 2016-02-01 A | 2016-02-05 → 2016-02-03 (-2d) | 5d → 3d | 0% → 99% |  |  | was named Order software; resources Intuit QuickBooks 2016 [1 License]; Symantec Antivirus [14 License]; Claims Software [14 License]; Google Apps [14 License]; Oracle Database Software [1 License] → Claims Software [1 License]; Google Apps [1 License]; Intuit QuickBooks 2016 [1 License]; Oracle Database Software [1 License]; Symantec Antivirus [1 License]; baseline start none → 2016-02-01; baseline finish none → 2016-02-03 |
| 19 | 1.3.1 Write up purchase orders | 2016-02-01 A | 2016-02-01 A |  | 0% → 100% | 87d → none |  | was named Write up purchase orders and purchase software; constraint start no earlier than 2016-02-01 → none; baseline start none → 2016-02-01; baseline finish none → 2016-02-01 |
| 20 | **1.4 Order networking** | 2016-02-01 → 2016-02-05 A (+4d) | 2016-02-04 → 2016-02-05 (+1d) | 4d → 1d | 0% → 99% |  |  | was named Order networking and hardware; resources Broadband Service [1 License]; Cat 6e Cable [1 Unit]; Docking Station [14 Unit]; Firewall [1 Unit]; Junction Box [2 Unit]; Keyboard/Mouse [14 Unit]; Laptop [14 Unit]; Monitor [14 Unit]; Printer [1 Unit]; RJ-45 Connector Tips [2 Pack]; RJ-45 Outlet [14 Unit]; Router [1 Unit]; Surge Protector [14 Unit]; Switch [1 Unit]; WiFi Range Extender [1 Unit]; WiFi Router [1 Unit] → Broadband Service [1 License]; Cat 6e Cable [1 Unit]; Docking Station [1 Unit]; Firewall [1 Unit]; Keyboard/Mouse [1 Unit]; Laptop [1 Unit]; Monitor [1 Unit]; RJ-45 Connector Tips [1 Pack]; RJ-45 Outlet [1 Unit]; Router [1 Unit]; Surge Protector [1 Unit]; Switch [1 Unit]; WiFi Range Extender [1 Unit]; WiFi Router [1 Unit]; baseline start none → 2016-02-05; baseline finish none → 2016-02-05 |
| 21 | 1.4.1 Write up purchase orders | 2016-02-01 → 2016-02-05 A (+4d) | 2016-02-01 → 2016-02-05 A (+4d) |  | 0% → 100% | 87d → none |  | was named Write up purchase orders; constraint start no earlier than 2016-02-01 → none; baseline start none → 2016-02-05; baseline finish none → 2016-02-05 |
| 23 | **1.5 Install hardware** | 2016-02-08 → 2016-03-08 (+29d) | 2016-02-12 → 2016-04-27 (+75d) | 5d → 37d | 0% → 54% | 58d → none | 18, 20 → 18, 20, 22 | was named Install hardware; baseline start none → 2016-02-08; baseline finish none → 2016-03-29 |
| 24 | 1.5.1 Determine needs for each office | 2016-02-08 A | 2016-02-10 → 2016-02-12 A (+2d) | 3d → 5d | 0% → 100% | 60d → none |  | was named Determine needs for each office; baseline start none → 2016-02-08; baseline finish none → 2016-02-12 |
| 25 | 1.5.2 Determine room readiness | 2016-02-08 → 2016-04-07 (+59d) | 2016-02-08 → 2016-04-13 (+65d) | 1d → 5d |  | 62d → 10d |  | was named Determine room readiness; baseline start none → 2016-03-09; baseline finish none → 2016-03-15 |
| 26 | 1.5.3 Determine room layouts and specifications | 2016-02-08 → 2016-04-14 (+66d) | 2016-02-09 → 2016-04-20 (+71d) | 2d → 5d |  | 61d → 5d |  | was named Determine room layouts and specifications; baseline start none → 2016-03-16; baseline finish none → 2016-03-22 |
| 27 | 1.5.4 Configure hardware | 2016-02-08 → 2016-03-24 A (+45d) | 2016-02-10 → 2016-04-21 (+71d) | 3d → 10d | 0% → 50% | 60d → 4d |  | was named Configure hardware; baseline start none → 2016-02-24; baseline finish none → 2016-03-23 |
| 28 | 1.5.5 Determine technical defects | 2016-02-08 → 2016-03-08 A (+29d) | 2016-02-11 → 2016-03-15 A (+33d) | 4d → 6d | 0% → 100% | 58d → none |  | was named Determine technical defects; baseline start none → 2016-02-08; baseline finish none → 2016-02-15 |
| 29 | 1.5.6 Determine defects and make fixes | 2016-02-08 → 2016-04-22 (+74d) | 2016-02-10 → 2016-04-27 (+77d) | 3d → 4d |  | 60d → 0d |  | was named Determine defects and make fixes; baseline start none → 2016-03-24; baseline finish none → 2016-03-29 |
| 30 | 1.5.7 Remedy technical defects | 2016-02-08 → 2016-03-16 A (+37d) | 2016-02-10 → 2016-03-18 A (+37d) |  | 0% → 100% | 59d → none |  | was named Remedy technical defects; baseline start none → 2016-02-16; baseline finish none → 2016-02-18 |
| 31 | 1.5.8 Verify defect fixes | 2016-02-12 → 2016-03-19 A (+36d) | 2016-02-12 → 2016-03-23 A (+40d) | 1d → 3d | 0% → 100% | 58d → none |  | was named Verify defect fixes; baseline start none → 2016-02-19; baseline finish none → 2016-02-23 |
| 32 | **1.6 Install Software** | 2016-02-15 → 2016-04-28 (+73d) | 2016-02-19 → 2016-07-05 (+137d) | 5d → 49d |  | 58d → -124d |  | was named Install Software; baseline start none → 2016-03-30; baseline finish none → 2016-06-03 |
| 33 | 1.6.1 Install patient registration component | 2016-02-15 → 2016-04-28 (+73d) | 2016-02-19 → 2016-07-05 (+137d) | 5d → 12d |  | 58d → -124d |  | was named Install patient registration component; baseline start none → 2016-03-30; baseline finish none → 2016-04-14 |
| 34 | 1.6.2 Check on Cisco Vital Software Interface requirements | 2016-02-15 → 2016-04-28 (+73d) | 2016-02-15 → 2016-06-01 (+107d) | 1d → 12d |  | 62d → -100d |  | was named Check on Cisco Vital Software Interface requirements; baseline start none → 2016-03-30; baseline finish none → 2016-04-14 |
| 35 | 1.6.3 Verify that Cisco Vital Software and Third Party medical devices meet requirements | 2016-02-15 → 2016-05-03 (+78d) | 2016-02-17 → 2016-05-18 (+91d) | 3d → 12d |  | 60d → -90d |  | was named Verify that Cisco Vital Software and Third Party medical devices meet requirements; baseline start none → 2016-03-30; baseline finish none → 2016-04-14 |
| 36 | 1.6.4 Produce mockups with hyperlinks to requirements | 2016-02-15 → 2016-05-16 (+91d) | 2016-02-17 → 2016-05-31 (+104d) | 3d → 12d |  | 60d → -99d |  | was named Produce mockups with hyperlinks to requirements; baseline start none → 2016-04-15; baseline finish none → 2016-05-02 |
| 37 | 1.6.5 System testing | 2016-02-15 → 2016-06-02 (+108d) | 2016-02-19 → 2016-06-17 (+119d) | 5d → 12d |  | 58d → -112d |  | was named System testing; baseline start none → 2016-05-04; baseline finish none → 2016-05-19 |
| 38 | 1.6.6 Develop user interface | 2016-02-15 → 2016-05-16 (+91d) | 2016-02-18 → 2016-05-31 (+103d) | 4d → 12d |  | 59d → -99d |  | was named Develop user interface; baseline start none → 2016-04-15; baseline finish none → 2016-05-02 |
| 39 | 1.6.7 Configure the software | 2016-02-15 → 2016-06-01 (+107d) | 2016-02-18 → 2016-06-16 (+119d) | 4d → 12d |  | 59d → -111d |  | was named Configure the software; baseline start none → 2016-05-03; baseline finish none → 2016-05-18 |
| 40 | 1.6.8 Perform integration testing | 2016-02-15 → 2016-06-17 (+123d) | 2016-02-19 → 2016-07-04 (+136d) | 5d → 12d |  | 58d → -123d |  | was named Perform integration testing; baseline start none → 2016-05-19; baseline finish none → 2016-06-03 |
| 41 | **1.7 Install networking** | 2016-03-08 → 2016-04-08 (+31d) | 2016-04-12 → 2016-05-13 (+31d) |  |  |  |  | was named Install networking; baseline start none → 2016-03-08; baseline finish none → 2016-04-12 |
| 42 | 1.7.1 Determine network needs | 2016-03-08 → 2016-07-06 (+120d) | 2016-03-08 → 2016-07-15 (+129d) | 1d → 8d |  | 61d → -45d |  | was named Determine network needs; baseline start none → 2016-06-15; baseline finish none → 2016-06-24 |
| 43 | 1.7.2 Determine networking infrastructure needs | 2016-03-08 → 2016-05-09 (+62d) | 2016-03-08 → 2016-08-15 (+160d) | 1d → 8d |  | 47d → -82d |  | was named Determine networking infrastructure needs; baseline start none → 2016-03-08; baseline finish none → 2016-06-14 |
| 44 | 1.7.3 Configure Financial Management Software | 2016-03-09 → 2016-08-16 (+160d) | 2016-03-11 → 2016-08-18 (+160d) |  |  | 47d → -82d |  | was named Configure Financial Management Software; baseline start none → 2016-06-15; baseline finish none → 2016-06-17 |
| 45 | 1.7.4 Configure Insurance Management Software | 2016-03-14 → 2016-08-19 (+158d) | 2016-03-16 → 2016-08-24 (+161d) | 3d → 4d |  | 47d → -82d |  | was named Configure Insurance Management Software; baseline start none → 2016-06-20; baseline finish none → 2016-06-23 |
| 46 | 1.7.5 Configure Xray Management Software | 2016-03-17 → 2016-08-25 (+161d) | 2016-03-21 → 2016-08-30 (+162d) | 3d → 4d |  | 47d → -82d |  | was named Configure Xray Management Software; baseline start none → 2016-06-24; baseline finish none → 2016-06-29 |
| 47 | 1.7.6 Test all software | 2016-03-22 → 2016-08-31 (+162d) | 2016-03-28 → 2016-09-06 (+162d) |  |  | 47d → -82d |  | was named Test all software; baseline start none → 2016-06-30; baseline finish none → 2016-07-06 |
| 48 | **1.8 Create management protocol** |  |  |  |  |  |  | was named Create management protocol; baseline start none → 2016-04-08; baseline finish none → 2016-04-14 |
| 49 | 1.8.1 Create maintenance plan |  |  |  |  | 8d → 4d |  | was named Create maintenance plan; baseline start none → 2016-04-08; baseline finish none → 2016-04-08 |
| 51 | 1.8.2 Create maintenance notification messaging | 2016-04-08 → 2016-04-11 (+3d) | 2016-04-08 → 2016-04-11 (+3d) |  |  | 8d → 3d |  | was named Create maintenance notification messaging; baseline start none → 2016-04-11; baseline finish none → 2016-04-11 |
| 52 | **1.9 Manage the project and team** |  |  |  |  |  |  | was named Manage the project and team; baseline start none → 2016-04-15; baseline finish none → 2016-04-27 |
| 53 | **1.9.1 Review of the workplan** |  |  |  |  |  |  | was named Review of the workplan; baseline start none → 2016-04-21; baseline finish none → 2016-04-27 |
| 54 | 1.9.1.1 Identify completed activities |  |  |  |  | 21d → 2d |  | was named Identify completed activities; baseline start none → 2016-04-21; baseline finish none → 2016-04-25 |
| 55 | 1.9.1.2 Check for variances in the schedule |  |  |  |  | 21d → 2d |  | was named Check for variances in the schedule; baseline start none → 2016-04-21; baseline finish none → 2016-04-25 |
| 56 | 1.9.2 Review the team morale |  |  |  |  | 25d → 31d |  | was named Review the team morale; baseline start none → 2016-04-15; baseline finish none → 2016-04-19 |
| 57 | **1.10 Control of the Project** |  | 2016-04-19 → 2016-04-27 (+8d) | 3d → 9d |  |  |  | was named Control of the Project; baseline start none → 2016-04-15; baseline finish none → 2016-04-27 |
| 58 | 1.10.1 Guard against scope creep |  |  |  |  | 25d → 31d |  | was named Guard against scope creep; baseline start none → 2016-04-15; baseline finish none → 2016-04-19 |
| 59 | 1.10.2 Check for the need for scope changes | 2016-04-15 → 2016-04-20 (+5d) | 2016-04-19 → 2016-04-27 (+8d) |  |  |  |  | was named Check for the need for scope changes; baseline start none → 2016-04-20; baseline finish none → 2016-04-27 |
| 60 | **1.11 Monitor the Project** |  | 2016-04-19 → 2016-05-02 (+13d) | 3d → 12d |  | 25d → 22d |  | was named Monitor the Project; baseline start none → 2016-04-15; baseline finish none → 2016-05-02 |
| 61 | 1.11.1 Evaluate project deliverables | 2016-04-15 → 2016-04-28 (+13d) | 2016-04-19 → 2016-05-02 (+13d) |  |  | 25d → 22d |  | was named Evaluate project deliverables; baseline start none → 2016-04-28; baseline finish none → 2016-05-02 |
| 62 | 1.11.2 Check on the budget |  |  |  |  | 25d → 31d |  | was named Check on the budget; baseline start none → 2016-04-15; baseline finish none → 2016-04-19 |
| 63 | **1.12 Project Meetings and Training** | 2016-04-28 → 2016-09-07 (+132d) | 2016-05-24 → 2016-09-28 (+127d) | 19d → 16d |  | 4d → none |  | was named Project Meetings and Training; baseline start none → 2016-05-03; baseline finish none → 2016-05-24 |
| 64 | 1.12.1 Define users | 2016-04-28 → 2016-09-07 (+132d) | 2016-04-28 → 2016-09-07 (+132d) |  |  | 22d → 15d |  | was named Define users; baseline start none → 2016-05-03; baseline finish none → 2016-05-03 |
| 65 | 1.12.2 Explain in basic terms how systems hardware and software works | 2016-04-28 → 2016-09-07 (+132d) | 2016-04-28 → 2016-09-07 (+132d) |  |  | 22d → 15d |  | was named Explain in basic terms how systems hardware and software works; baseline start none → 2016-05-03; baseline finish none → 2016-05-03 |
| 66 | 1.12.3 Explain how to interpret data | 2016-04-28 → 2016-09-07 (+132d) | 2016-04-28 → 2016-09-07 (+132d) |  |  | 22d → 15d |  | was named Explain how to interpret data; baseline start none → 2016-05-03; baseline finish none → 2016-05-03 |
| 67 | 1.12.4 Explain how to store data properly | 2016-04-28 → 2016-09-08 (+133d) | 2016-04-28 → 2016-09-08 (+133d) |  |  | 22d → 14d |  | was named Explain how to store data properly; baseline start none → 2016-05-04; baseline finish none → 2016-05-04 |
| 68 | 1.12.5 Receptionist Training | 2016-05-03 → 2016-09-07 (+127d) | 2016-05-03 → 2016-09-13 (+133d) | 1d → 5d |  | 19d → -1d |  | was named Receptionist Training; constraint start no earlier than 2016-05-03 → start no earlier than 2016-09-07; baseline start none → 2016-05-03; baseline finish none → 2016-05-09 |
| 69 | 1.12.6 Dental Staff Training | 2016-05-10 → 2016-09-14 (+127d) | 2016-05-13 → 2016-09-20 (+130d) | 4d → 5d |  | 11d → -1d | none → 68 | was named Dental Staff Training; constraint start no earlier than 2016-05-10 → none; baseline start none → 2016-05-10; baseline finish none → 2016-05-16 |
| 70 | 1.12.7 Accounting and Administrative Training | 2016-05-16 → 2016-09-21 (+128d) | 2016-05-19 → 2016-09-27 (+131d) | 4d → 5d |  | 7d → -1d | none → 69 | was named Accounting and Administrative Training; baseline start none → 2016-05-17; baseline finish none → 2016-05-23 |
| 71 | 1.12.8 Quiz session | 2016-05-23 → 2016-09-28 (+128d) | 2016-05-23 → 2016-09-28 (+128d) |  |  | 4d → -1d | none → 70 | was named Quiz session; baseline start none → 2016-05-23; baseline finish none → 2016-05-23 |
| 72 | 1.12.9 List responsibilities of IT liaison | 2016-05-24 → 2016-09-29 (+128d) | 2016-05-24 → 2016-09-29 (+128d) |  |  | 4d → -1d |  | was named List responsibilities of IT liaison; baseline start none → 2016-05-24; baseline finish none → 2016-05-24 |
| 73 | **1.13 Project close-out** | 2016-05-25 → 2016-09-30 (+128d) | 2016-05-30 → 2016-10-05 (+128d) |  |  |  |  | was named Project close-out; baseline start none → 2016-05-25; baseline finish none → 2016-05-30 |

| ID | Task | Start | Finish | Duration | Total float | Other |
| --- | --- | --- | --- | --- | --- | --- |
| 74 | 1.13.1 Close out documentation | 2016-05-25 → 2016-09-30 (+128d) | 2016-05-25 → 2016-10-03 (+131d) | 1d → 2d | 4d → -1d | was named Establish Feedback System; baseline start none → 2016-05-25; baseline finish none → 2016-05-26 |
| 75 | 1.13.2 Outline lessons learned | 2016-05-26 → 2016-10-04 (+131d) | 2016-05-26 → 2016-10-06 (+133d) | 1d → 2d | 4d → -1d | was named Outline lessons learned; baseline start none → 2016-05-27; baseline finish none → 2016-05-30 |
| 76 | 1.13.3 Project closure phase complete | 2016-05-30 → 2016-10-04 (+127d) | 2016-05-30 → 2016-10-05 (+128d) | 0.5d → 2d | 2.5d → 1d | was named Close out documentation and signatures; baseline start none → 2016-05-30; baseline finish none → 2016-05-31 |
